# Ut cancha

Schedule from MS Project, 2022-02-09 to 2022-03-28, 9 hours a day.

## Calendars

- Estándar: Mon-Fri 07:00-12:00, 13:00-17:00; Sat 07:00-10:00; Sun off.

## Schedule

| ID | Task | Type | Duration | Start | Finish | Predecessors | Total slack |
| --- | --- | --- | --- | --- | --- | --- | --- |
| 1 | Inicio | manual | 1d | 2022-02-09 | 2022-02-10 |  |  |
| 2 | Verificacion de ejes y alineamientos |  | 1d | 2022-02-09 | 2022-02-10 |  | 0d |
| 3 | Excavacion mecanica para cimentacion |  | 1d | 2022-02-10 | 2022-02-11 | 2 | 0d |
| 4 | Zapata Centrica 0,8*0,8 m Incluye Acero |  | 2d | 2022-02-11 | 2022-02-14 | 3 | 0d |
| 5 | Zapata Excentrica 0,8*0,6 m Incluye Acero |  | 2d | 2022-02-11 | 2022-02-14 | 3 | 0d |
| 6 | Viga de amarre longitudinas 30 m de B=0,25;h=0,3m |  | 4d | 2022-02-14 | 2022-02-18 | 4, 5 | 0d |
| 7 | Viga amarre transversal de 1,4m; B=0,25*h=0,3m |  | 3d | 2022-02-18 | 2022-02-23 | 6 | 0d |
| 8 | Columna interior de 1,5m ;b=0,3;h=0,3m |  | 2d | 2022-02-23 | 2022-02-25 | 7 | 1d |
| 9 | Columna exterior de 2,5; b=0,3;h=0,3m |  | 3d | 2022-02-23 | 2022-02-28 | 7 | 0d |
| 10 | Relleno y compactacion Nivel viga de confinamiento |  | 2d | 2022-02-28 | 2022-03-02 | 8, 9 | 0d |
| 11 | Viga inclinada de 3,45m; b=0,3 h=0,3 |  | 5d | 2022-03-02 | 2022-03-08 | 10 | 1d |
| 12 | Viga de confinamiento de 30m; B=0,3; h=0,3 |  | 6d | 2022-03-02 | 2022-03-09 | 10 | 0d |
| 13 | Losa para gradería en concreto reforzado, huella B= 0,8x e=0,1 |  | 8d | 2022-03-09 | 2022-03-21 | 11, 12 | 0d |
| 14 | Mampostería en ladrillo macizo de arcilla cocida de7x10x20cm para Contra huella de 0,3m |  | 2d | 2022-03-21 | 2022-03-23 | 13 | 0d |
| 15 | Mampostería confinada en ladrillo h15 15x20x30cm para costados |  | 3d | 2022-03-21 | 2022-03-24 | 13 | 3d |
| 16 | Friso para maposteria dosificacion 1:4 |  | 2d | 2022-03-23 | 2022-03-25 | 14 | 0d |
| 17 | Aseo |  | 33d | 2022-02-11 | 2022-03-26 | 2FS+1d | 1d |
| 18 | Estuco y pintura |  | 2d | 2022-03-25 | 2022-03-28 | 16 | 0d |
| 19 | FIN | milestone, manual | 0d | 2022-03-28 | 2022-03-28 | 15, 18, 17 |  |
